# AL-05 - moeilijke bouwput

Schedule from MS Project, 2003-01-12 to 2003-02-25, status date 2003-01-08.
BAM Nelissen Van Egteren

## Calendars

- ALLEEN WERKDAGEN: Mon-Fri 08:30-12:30, 13:00-17:00; Sat-Sun off. Exceptions (off unless hours are given): 2003-01-11 to 2003-01-12 08:30-12:30, 13:00-17:00, 2003-01-18 to 2003-01-19 08:30-12:30, 13:00-17:00, 2003-01-25 to 2003-01-26 08:30-12:30, 13:00-17:00, 2003-02-01 to 2003-02-02 08:30-12:30, 13:00-17:00, 2003-02-08 to 2003-02-09 08:30-12:30, 13:00-17:00, 2003-02-15 to 2003-02-16 08:30-12:30, 13:00-17:00, 2003-02-22 to 2003-02-23 08:30-12:30, 13:00-17:00.

## Schedule

| ID | WBS | Task | Type | Duration | Start | Finish | Predecessors | Total slack |
| --- | --- | --- | --- | --- | --- | --- | --- | --- |
| 1 | 1 | **AANLOOPFASE** |  | 45d | 2003-01-12 | 2003-02-25 |  | 0d |
| 2 | 1.1 | keten/loodsen/afrastering |  | 10d | 2003-01-12 | 2003-01-21 |  | 0d |
| 3 | 1.2 | bouwinstallatie aanleggen |  | 10d | 2003-01-12 | 2003-01-21 | 2SS | 0d |
| 4 | 1.3 | bouwwegen aanleggen |  | 9d | 2003-01-13 | 2003-01-21 | 3SS+1d | 0d |
| 5 | 1.4 | uitzetten+bouwplanken |  | 5d | 2003-01-15 | 2003-01-19 | 4SS+2d | 0d |
| 6 | 1.5 | bouwput ondiep ontgraven |  | 7d | 2003-01-18 | 2003-01-24 | 5SS+3d | 0d |
| 7 | 1.6 | bronbemaling aanleggen |  | 5d | 2003-01-22 | 2003-01-26 | 6SS+4d | 0d |
| 8 | 1.7 | sleuf hoofddrain ontgraven |  | 4d | 2003-01-26 | 2003-01-29 | 7SS+4d | 0d |
| 9 | 1.8 | hoofddrainleiding aanleggen |  | 4d | 2003-01-28 | 2003-01-31 | 8SS+2d | 0d |
| 10 | 1.9 | diepdrainage infraisen |  | 5d | 2003-02-01 | 2003-02-05 | 9SS+4d | 0d |
| 11 | 1.10 | boorpalen heien |  | 9d | 2003-02-05 | 2003-02-13 | 10SS+4d | 0d |
| 12 | 1.11 | paalkoppen snellen |  | 7d | 2003-02-10 | 2003-02-16 | 11SS+5d | 0d |
| 13 | 1.12 | boorpalen kop opstorten |  | 7d | 2003-02-12 | 2003-02-18 | 12SS+2d | 0d |
| 14 | 1.13 | diepe kelder ontgraven |  | 5d | 2003-02-15 | 2003-02-19 | 13SS+3d | 0d |
| 15 | 1.14 | paalkoppen kelder snellen |  | 2d | 2003-02-20 | 2003-02-21 | 14SS+5d | 0d |
| 16 | 1.15 | paalkoppen afvoeren |  | 2d | 2003-02-22 | 2003-02-23 | 15SS+2d | 0d |
| 17 | 1.16 | maatvoeren fundering |  | 2d | 2003-02-24 | 2003-02-25 | 16SS+2d | 0d |
| 18 | 1.17 | start onderbouw | milestone | 0d | 2003-02-25 | 2003-02-25 | 17SS+2d | 0d |
